# DIQUES NATURALIZADOS

Schedule from Primavera P6, 2024-12-01 to 2025-06-23, data date 2024-12-01.

## Calendars

- Calendario Dias Calendario: Mon-Sun 07:00-12:00, 13:00-18:00.

## Resources

| Resource | Group |
| --- | --- |
| CAPATAZ | labor |
| OPERARIO | labor |
| OFICIAL | labor |
| PEON | labor |
| VOLQUETES | equipment |
| CISTERNA | equipment |
| CAMION GRUA BARANDA 3 TN | equipment |
| CARGADOR FRONTAL | equipment |
| EXCAVADORA SOBRE ORUGAS 180-348 HP | equipment |
| DUMPER DE DESCARGA FRONTA 2 TN | equipment |
| MOTONIVELADORA 145 -150HP | equipment |
| TRACTOR SOBREORUGAS 300-330HP | equipment |
| TRACTOR SOBREORUGAS 170-220HP | equipment |
| RETROEXCAVADORA | equipment |
| MIXER DE CONCRETO | equipment |
| RODILLO BERMERO | equipment |
| RODILLO LISO VIBR. AUTOPROPULSADO 101-135HP 10-12TN | equipment |
| EXCAVACION | material |
| PERFILADO | material |
| RELLENOS | material |
| TIERRA APISONADA | material |
| BORDILLOS | material |

## Schedule

| ID | WBS | Activity | Type | Duration | Start | Finish | Predecessors | Total float | Free float | Resources | Licitacion |
| --- | --- | --- | --- | --- | --- | --- | --- | --- | --- | --- | --- |
|  | .0 | **HITOS** |  |  | 2024-12-01 | 2025-06-23 |  |  |  |  |  |
| H1000 |  | KOM | milestone | 0d | 2024-12-01 | 2024-12-01 |  | 0d |  |  |  |
| H1100 |  | INICIO DE PLAZO CONTRACTUAL - ACCESO AL SITIO | milestone | 0d | 2024-12-17 | 2024-12-17 | A1040 | 189d |  |  |  |
| H1200 |  | FIN DE PLAZO CONTRACTUAL - CULMINACION DE OBRAS | milestone | 0d | 2025-06-23 | 2025-06-23 | A1400 FF | 0d |  |  |  |
|  | 1 | **TRANSPORTE DE MATERIAL** |  |  | 2024-12-17 | 2025-04-13 |  |  |  |  |  |
| A1020 |  | TRANSPORTE DE MATERIAL EXCEDENTE PARA DISTANCIAS <1KM | level of effort | 118d | 2024-12-17 | 2025-04-13 | A1690 SS | 71d | 0d | CAPATAZ; OPERARIO [669.3 h]; OFICIAL; PEON [334.65 h]; VOLQUETES [669.3 h]; CISTERNA; CAMION GRUA BARANDA 3 TN; CARGADOR FRONTAL; EXCAVADORA SOBRE ORUGAS 180-348 HP [167.32 h]; DUMPER DE DESCARGA FRONTA 2 TN; MOTONIVELADORA 145 -150HP; TRACTOR SOBREORUGAS 300-330HP; TRACTOR SOBREORUGAS 170-220HP; RETROEXCAVADORA; MIXER DE CONCRETO; RODILLO BERMERO; RODILLO LISO VIBR. AUTOPROPULSADO 101-135HP 10-12TN |  |
| A1030 |  | TRANSPORTE DE MATERIAL EXCEDENTE PARA DISTANCIAS >1KM | level of effort | 118d | 2024-12-17 | 2025-04-13 | A1690 SS | 71d | 0d | CAPATAZ; OPERARIO; OFICIAL; PEON; VOLQUETES [5649.23 h]; CISTERNA; CAMION GRUA BARANDA 3 TN; CARGADOR FRONTAL; EXCAVADORA SOBRE ORUGAS 180-348 HP; DUMPER DE DESCARGA FRONTA 2 TN; MOTONIVELADORA 145 -150HP; TRACTOR SOBREORUGAS 300-330HP; TRACTOR SOBREORUGAS 170-220HP; RETROEXCAVADORA; MIXER DE CONCRETO; RODILLO BERMERO; RODILLO LISO VIBR. AUTOPROPULSADO 101-135HP 10-12TN |  |
| A1000 |  | TRANSPORTE DE MATERIAL GRANULAR PARA DISTANCIAS <1KM | level of effort | 107d | 2024-12-19 | 2025-04-04 | A1710 SS | 71d | 0d | CAPATAZ; OPERARIO [589.08 h]; OFICIAL; PEON [294.54 h]; VOLQUETES [589.08 h]; CISTERNA; CAMION GRUA BARANDA 3 TN; CARGADOR FRONTAL; EXCAVADORA SOBRE ORUGAS 180-348 HP [147.27 h]; DUMPER DE DESCARGA FRONTA 2 TN; MOTONIVELADORA 145 -150HP; TRACTOR SOBREORUGAS 300-330HP; TRACTOR SOBREORUGAS 170-220HP; RETROEXCAVADORA; MIXER DE CONCRETO; RODILLO BERMERO; RODILLO LISO VIBR. AUTOPROPULSADO 101-135HP 10-12TN | RELL |
| A1010 |  | TRANSPORTE DE MATERIAL GRANULAR PARA DISTANCIAS >1KM | level of effort | 107d | 2024-12-19 | 2025-04-04 | A1710 SS | 71d | 0d | CAPATAZ; OPERARIO; OFICIAL; PEON; VOLQUETES [7634.86 h]; CISTERNA; CAMION GRUA BARANDA 3 TN; CARGADOR FRONTAL; EXCAVADORA SOBRE ORUGAS 180-348 HP; DUMPER DE DESCARGA FRONTA 2 TN; MOTONIVELADORA 145 -150HP; TRACTOR SOBREORUGAS 300-330HP; TRACTOR SOBREORUGAS 170-220HP; RETROEXCAVADORA; MIXER DE CONCRETO; RODILLO BERMERO; RODILLO LISO VIBR. AUTOPROPULSADO 101-135HP 10-12TN | RELL |
|  | 2 | **INTERVENCIÓN PAISAJISMO - HUMEDAL VILLA MARIA MARGEN DERECHO - ARQUITECTURA Y PAISAJISMO** |  |  | 2024-12-01 | 2025-06-12 |  |  |  |  |  |
|  | 1 | **OBRAS PRELIMINARES** |  |  | 2024-12-01 | 2025-03-19 |  |  |  |  |  |
| A1040 |  | MOVILIZACIÓN Y DEMOVILIZACIÓN DE EQUIPOS Y HERRAMIENTAS (ARQUITECTURA Y PAISAJISMO) |  | 16d | 2024-12-01 | 2024-12-16 | H1000 SS | 0d |  | CAPATAZ; OPERARIO; OFICIAL; PEON; VOLQUETES; CISTERNA; CAMION GRUA BARANDA 3 TN; CARGADOR FRONTAL; EXCAVADORA SOBRE ORUGAS 180-348 HP; DUMPER DE DESCARGA FRONTA 2 TN; MOTONIVELADORA 145 -150HP; TRACTOR SOBREORUGAS 300-330HP; TRACTOR SOBREORUGAS 170-220HP; RETROEXCAVADORA; MIXER DE CONCRETO; RODILLO BERMERO; RODILLO LISO VIBR. AUTOPROPULSADO 101-135HP 10-12TN |  |
| A1050 |  | TRAZO Y REPLANTEO PRELIMINAR |  | 31d | 2024-12-08 | 2025-01-07 | H1000 SS+7d | 9d | 0d | CAPATAZ; OPERARIO [603.41 h]; OFICIAL [603.41 h]; PEON [1206.81 h]; VOLQUETES; CISTERNA; CAMION GRUA BARANDA 3 TN; CARGADOR FRONTAL; EXCAVADORA SOBRE ORUGAS 180-348 HP; DUMPER DE DESCARGA FRONTA 2 TN; MOTONIVELADORA 145 -150HP; TRACTOR SOBREORUGAS 300-330HP; TRACTOR SOBREORUGAS 170-220HP; RETROEXCAVADORA; MIXER DE CONCRETO; RODILLO BERMERO; RODILLO LISO VIBR. AUTOPROPULSADO 101-135HP 10-12TN |  |
| A1060 |  | ELIMINACION DE RESIDUOS SOLIDOS GENERALES MUNICIPALES |  | 91d | 2024-12-19 | 2025-03-19 | A1690 | 81d | 70d | CAPATAZ [362.19 h]; OPERARIO [362.19 h]; OFICIAL [1810.93 h]; PEON [3621.86 h]; VOLQUETES [3621.86 h]; CISTERNA; CAMION GRUA BARANDA 3 TN; CARGADOR FRONTAL; EXCAVADORA SOBRE ORUGAS 180-348 HP [3621.86 h]; DUMPER DE DESCARGA FRONTA 2 TN; MOTONIVELADORA 145 -150HP; TRACTOR SOBREORUGAS 300-330HP [1810.93 h]; TRACTOR SOBREORUGAS 170-220HP; RETROEXCAVADORA; MIXER DE CONCRETO; RODILLO BERMERO; RODILLO LISO VIBR. AUTOPROPULSADO 101-135HP 10-12TN; EXCAVACION [63382.6] |  |
|  | 6 | **FASE 1 - TRAMOS SIN RESTRICCION PREDIAL** |  |  | 2024-12-01 | 2025-02-23 |  |  |  |  |  |
|  | 2 | **MOVIMIENTO DE TIERRAS** |  |  | 2024-12-01 | 2025-02-23 |  |  |  |  |  |
| A1740 |  | ELIMINACION DE MATERIAL EXCEDENTE (DME´S) |  | 0d | 2024-12-01 | 2024-12-01 |  | 205d |  |  |  |
|  | 3 | **PK 0+000 - PK 0+300** |  |  | 2024-12-17 | 2025-02-19 |  |  |  |  |  |
| A1690 |  | CORTE PARA CIMENTACIÓN DE DIQUE NATURALIZADO h=30cm |  | 2d | 2024-12-17 | 2024-12-18 | A1040, A1050 SS | 0d |  | CAPATAZ [16.71 h]; OPERARIO [16.71 h]; OFICIAL [16.71 h]; PEON [100.26 h]; VOLQUETES; CISTERNA; CAMION GRUA BARANDA 3 TN; CARGADOR FRONTAL; EXCAVADORA SOBRE ORUGAS 180-348 HP [16.71 h]; DUMPER DE DESCARGA FRONTA 2 TN; MOTONIVELADORA 145 -150HP; TRACTOR SOBREORUGAS 300-330HP; TRACTOR SOBREORUGAS 170-220HP; RETROEXCAVADORA; MIXER DE CONCRETO; RODILLO BERMERO; RODILLO LISO VIBR. AUTOPROPULSADO 101-135HP 10-12TN; EXCAVACION [1086.2] | EXC |
| A1700 |  | PERFILADO Y COMPACTACION EN ZONA DE CORTE |  | 2d | 2024-12-17 | 2024-12-18 | A1690 SS | 0d |  | CAPATAZ [1.84 h]; OPERARIO; OFICIAL [18.37 h]; PEON [18.37 h]; VOLQUETES; CISTERNA [18.37 h]; CAMION GRUA BARANDA 3 TN; CARGADOR FRONTAL; EXCAVADORA SOBRE ORUGAS 180-348 HP [18.37 h]; DUMPER DE DESCARGA FRONTA 2 TN; MOTONIVELADORA 145 -150HP [18.37 h]; TRACTOR SOBREORUGAS 300-330HP; TRACTOR SOBREORUGAS 170-220HP [9.19 h]; RETROEXCAVADORA; MIXER DE CONCRETO; RODILLO BERMERO; RODILLO LISO VIBR. AUTOPROPULSADO 101-135HP 10-12TN [18.37 h]; PERFILADO [5512.24] | EXC |
| A1710 |  | CONFORMACIÓN DE CUERPO DE DIQUE NATURALZADO CON RELLENO COMPACTADO |  | 6d | 2024-12-19 | 2024-12-24 | A1700 | 0d |  | CAPATAZ [5.85 h]; OPERARIO [58.47 h]; OFICIAL [58.47 h]; PEON [116.94 h]; VOLQUETES; CISTERNA [58.47 h]; CAMION GRUA BARANDA 3 TN; CARGADOR FRONTAL [14.62 h]; EXCAVADORA SOBRE ORUGAS 180-348 HP; DUMPER DE DESCARGA FRONTA 2 TN; MOTONIVELADORA 145 -150HP [58.47 h]; TRACTOR SOBREORUGAS 300-330HP; TRACTOR SOBREORUGAS 170-220HP; RETROEXCAVADORA; MIXER DE CONCRETO; RODILLO BERMERO; RODILLO LISO VIBR. AUTOPROPULSADO 101-135HP 10-12TN [58.47 h]; RELLENOS [2923.57] | RELL |
| A1720 |  | EXCAVACIÓN MANUAL PARA INSTALACIÓN DE BORDILLOS Y CIMENTACIONES |  | 14d | 2024-12-25 | 2025-01-07 | A1710 | 0d |  | CAPATAZ; OPERARIO; OFICIAL [68.31 h]; PEON [273.25 h]; VOLQUETES; CISTERNA; CAMION GRUA BARANDA 3 TN; CARGADOR FRONTAL; EXCAVADORA SOBRE ORUGAS 180-348 HP; DUMPER DE DESCARGA FRONTA 2 TN; MOTONIVELADORA 145 -150HP; TRACTOR SOBREORUGAS 300-330HP; TRACTOR SOBREORUGAS 170-220HP; RETROEXCAVADORA; MIXER DE CONCRETO; RODILLO BERMERO; RODILLO LISO VIBR. AUTOPROPULSADO 101-135HP 10-12TN | EXC-MAN |
| A1730 |  | EXCAVACIÓN PARA MEJORAMIENTO DE SUELO CON TIERRA VEGETAL |  | 1d | 2025-02-19 | 2025-02-19 | A1720, A1820 | 8d | 0d | CAPATAZ [0.03 h]; OPERARIO [0.27 h]; OFICIAL [0.13 h]; PEON [0.27 h]; VOLQUETES; CISTERNA; CAMION GRUA BARANDA 3 TN; CARGADOR FRONTAL; EXCAVADORA SOBRE ORUGAS 180-348 HP [0.27 h]; DUMPER DE DESCARGA FRONTA 2 TN; MOTONIVELADORA 145 -150HP; TRACTOR SOBREORUGAS 300-330HP [0.13 h]; TRACTOR SOBREORUGAS 170-220HP; RETROEXCAVADORA; MIXER DE CONCRETO; RODILLO BERMERO; RODILLO LISO VIBR. AUTOPROPULSADO 101-135HP 10-12TN | EXC |
|  | 2 | **PK 0+422 - PK 0+920** |  |  | 2024-12-19 | 2025-02-20 |  |  |  |  |  |
| A1750 |  | CORTE PARA CIMENTACIÓN DE DIQUE NATURALIZADO h=30cm |  | 3d | 2024-12-19 | 2024-12-21 | A1690 | 3d | 0d | CAPATAZ [27.74 h]; OPERARIO [27.74 h]; OFICIAL [27.74 h]; PEON [166.44 h]; VOLQUETES; CISTERNA; CAMION GRUA BARANDA 3 TN; CARGADOR FRONTAL; EXCAVADORA SOBRE ORUGAS 180-348 HP [27.74 h]; DUMPER DE DESCARGA FRONTA 2 TN; MOTONIVELADORA 145 -150HP; TRACTOR SOBREORUGAS 300-330HP; TRACTOR SOBREORUGAS 170-220HP; RETROEXCAVADORA; MIXER DE CONCRETO; RODILLO BERMERO; RODILLO LISO VIBR. AUTOPROPULSADO 101-135HP 10-12TN; EXCAVACION [1803.09] | EXC |
| A1760 |  | PERFILADO Y COMPACTACION EN ZONA DE CORTE |  | 4d | 2024-12-22 | 2024-12-25 | A1750, A1700 | 3d | 0d | CAPATAZ [3.05 h]; OPERARIO; OFICIAL [30.5 h]; PEON [30.5 h]; VOLQUETES; CISTERNA [30.5 h]; CAMION GRUA BARANDA 3 TN; CARGADOR FRONTAL; EXCAVADORA SOBRE ORUGAS 180-348 HP [30.5 h]; DUMPER DE DESCARGA FRONTA 2 TN; MOTONIVELADORA 145 -150HP [30.5 h]; TRACTOR SOBREORUGAS 300-330HP; TRACTOR SOBREORUGAS 170-220HP [15.25 h]; RETROEXCAVADORA; MIXER DE CONCRETO; RODILLO BERMERO; RODILLO LISO VIBR. AUTOPROPULSADO 101-135HP 10-12TN [30.5 h]; RELLENOS [9150.32] | EXC |
| A1770 |  | CONFORMACIÓN DE CUERPO DE DIQUE NATURALZADO CON RELLENO COMPACTADO |  | 10d | 2024-12-26 | 2025-01-04 | A1760, A1710 | 3d | 0d | CAPATAZ [9.71 h]; OPERARIO [97.06 h]; OFICIAL [97.06 h]; PEON [194.13 h]; VOLQUETES; CISTERNA [97.06 h]; CAMION GRUA BARANDA 3 TN; CARGADOR FRONTAL [24.27 h]; EXCAVADORA SOBRE ORUGAS 180-348 HP; DUMPER DE DESCARGA FRONTA 2 TN; MOTONIVELADORA 145 -150HP [97.06 h]; TRACTOR SOBREORUGAS 300-330HP; TRACTOR SOBREORUGAS 170-220HP; RETROEXCAVADORA; MIXER DE CONCRETO; RODILLO BERMERO; RODILLO LISO VIBR. AUTOPROPULSADO 101-135HP 10-12TN [97.06 h]; RELLENOS [4853.13] | RELL |
| A1780 |  | EXCAVACIÓN MANUAL PARA INSTALACIÓN DE BORDILLOS Y CIMENTACIONES |  | 12d | 2025-01-08 | 2025-01-19 | A1770, A1720 | 0d |  | CAPATAZ; OPERARIO; OFICIAL [113.4 h]; PEON [453.6 h]; VOLQUETES; CISTERNA; CAMION GRUA BARANDA 3 TN; CARGADOR FRONTAL; EXCAVADORA SOBRE ORUGAS 180-348 HP; DUMPER DE DESCARGA FRONTA 2 TN; MOTONIVELADORA 145 -150HP; TRACTOR SOBREORUGAS 300-330HP; TRACTOR SOBREORUGAS 170-220HP; RETROEXCAVADORA; MIXER DE CONCRETO; RODILLO BERMERO; RODILLO LISO VIBR. AUTOPROPULSADO 101-135HP 10-12TN | EXC-MAN |
| A1790 |  | EXCAVACIÓN PARA MEJORAMIENTO DE SUELO CON TIERRA VEGETAL |  | 1d | 2025-02-20 | 2025-02-20 | A1780, A1730 | 8d | 0d | CAPATAZ [0.04 h]; OPERARIO [0.44 h]; OFICIAL [0.22 h]; PEON [0.44 h]; VOLQUETES; CISTERNA; CAMION GRUA BARANDA 3 TN; CARGADOR FRONTAL; EXCAVADORA SOBRE ORUGAS 180-348 HP [0.44 h]; DUMPER DE DESCARGA FRONTA 2 TN; MOTONIVELADORA 145 -150HP; TRACTOR SOBREORUGAS 300-330HP [0.22 h]; TRACTOR SOBREORUGAS 170-220HP; RETROEXCAVADORA; MIXER DE CONCRETO; RODILLO BERMERO; RODILLO LISO VIBR. AUTOPROPULSADO 101-135HP 10-12TN | EXC |

| ID | WBS | Activity | Duration | Start | Finish | Predecessors | Total float | Free float | Resources | Licitacion |
| --- | --- | --- | --- | --- | --- | --- | --- | --- | --- | --- |
|  | 4 | **PK 0+970 - PK 1+510** |  | 2024-12-22 | 2025-02-21 |  |  |  |  |  |
| A1630 |  | CORTE PARA CIMENTACIÓN DE DIQUE NATURALIZADO h=30cm | 4d | 2024-12-22 | 2024-12-25 | A1750 | 10d | 0d | CAPATAZ [30.08 h]; OPERARIO [30.08 h]; OFICIAL [30.08 h]; PEON [180.48 h]; VOLQUETES; CISTERNA; CAMION GRUA BARANDA 3 TN; CARGADOR FRONTAL; EXCAVADORA SOBRE ORUGAS 180-348 HP [30.08 h]; DUMPER DE DESCARGA FRONTA 2 TN; MOTONIVELADORA 145 -150HP; TRACTOR SOBREORUGAS 300-330HP; TRACTOR SOBREORUGAS 170-220HP; RETROEXCAVADORA; MIXER DE CONCRETO; RODILLO BERMERO; RODILLO LISO VIBR. AUTOPROPULSADO 101-135HP 10-12TN; EXCAVACION [1955.16] | EXC |
| A1640 |  | PERFILADO Y COMPACTACION EN ZONA DE CORTE | 4d | 2024-12-26 | 2024-12-29 | A1630, A1760 | 10d | 0d | CAPATAZ [3.31 h]; OPERARIO; OFICIAL [33.07 h]; PEON [33.07 h]; VOLQUETES; CISTERNA [33.07 h]; CAMION GRUA BARANDA 3 TN; CARGADOR FRONTAL; EXCAVADORA SOBRE ORUGAS 180-348 HP [33.07 h]; DUMPER DE DESCARGA FRONTA 2 TN; MOTONIVELADORA 145 -150HP [33.07 h]; TRACTOR SOBREORUGAS 300-330HP; TRACTOR SOBREORUGAS 170-220HP [16.54 h]; RETROEXCAVADORA; MIXER DE CONCRETO; RODILLO BERMERO; RODILLO LISO VIBR. AUTOPROPULSADO 101-135HP 10-12TN [33.07 h]; PERFILADO [9922.03] | EXC |
| A1650 |  | CONFORMACIÓN DE CUERPO DE DIQUE NATURALZADO CON RELLENO COMPACTADO | 11d | 2025-01-05 | 2025-01-15 | A1640, A1770 | 4d | 0d | CAPATAZ [10.52 h]; OPERARIO [105.25 h]; OFICIAL [105.25 h]; PEON [210.5 h]; VOLQUETES; CISTERNA [105.25 h]; CAMION GRUA BARANDA 3 TN; CARGADOR FRONTAL [26.31 h]; EXCAVADORA SOBRE ORUGAS 180-348 HP; DUMPER DE DESCARGA FRONTA 2 TN; MOTONIVELADORA 145 -150HP [105.25 h]; TRACTOR SOBREORUGAS 300-330HP; TRACTOR SOBREORUGAS 170-220HP; RETROEXCAVADORA; MIXER DE CONCRETO; RODILLO BERMERO; RODILLO LISO VIBR. AUTOPROPULSADO 101-135HP 10-12TN [105.25 h]; RELLENOS [5262.42] | RELL |
| A1660 |  | EXCAVACIÓN MANUAL PARA INSTALACIÓN DE BORDILLOS Y CIMENTACIONES | 13d | 2025-01-20 | 2025-02-01 | A1650, A1780 | 0d |  | CAPATAZ; OPERARIO; OFICIAL [122.96 h]; PEON [491.85 h]; VOLQUETES; CISTERNA; CAMION GRUA BARANDA 3 TN; CARGADOR FRONTAL; EXCAVADORA SOBRE ORUGAS 180-348 HP; DUMPER DE DESCARGA FRONTA 2 TN; MOTONIVELADORA 145 -150HP; TRACTOR SOBREORUGAS 300-330HP; TRACTOR SOBREORUGAS 170-220HP; RETROEXCAVADORA; MIXER DE CONCRETO; RODILLO BERMERO; RODILLO LISO VIBR. AUTOPROPULSADO 101-135HP 10-12TN | EXC-MAN |
| A1670 |  | EXCAVACIÓN PARA MEJORAMIENTO DE SUELO CON TIERRA VEGETAL | 1d | 2025-02-21 | 2025-02-21 | A1660, A1790 | 8d | 0d | CAPATAZ [0.05 h]; OPERARIO [0.48 h]; OFICIAL [0.24 h]; PEON [0.48 h]; VOLQUETES; CISTERNA; CAMION GRUA BARANDA 3 TN; CARGADOR FRONTAL; EXCAVADORA SOBRE ORUGAS 180-348 HP [0.48 h]; DUMPER DE DESCARGA FRONTA 2 TN; MOTONIVELADORA 145 -150HP; TRACTOR SOBREORUGAS 300-330HP [0.24 h]; TRACTOR SOBREORUGAS 170-220HP; RETROEXCAVADORA; MIXER DE CONCRETO; RODILLO BERMERO; RODILLO LISO VIBR. AUTOPROPULSADO 101-135HP 10-12TN | EXC |
|  | 5 | **PK 2+325 - PK 2+710** |  | 2024-12-26 | 2025-02-22 |  |  |  |  |  |
| A1570 |  | CORTE PARA CIMENTACIÓN DE DIQUE NATURALIZADO h=30cm | 2d | 2024-12-26 | 2024-12-27 | A1630 | 30d | 0d | CAPATAZ [21.45 h]; OPERARIO [21.45 h]; OFICIAL [21.45 h]; PEON [128.67 h]; VOLQUETES; CISTERNA; CAMION GRUA BARANDA 3 TN; CARGADOR FRONTAL; EXCAVADORA SOBRE ORUGAS 180-348 HP [21.45 h]; DUMPER DE DESCARGA FRONTA 2 TN; MOTONIVELADORA 145 -150HP; TRACTOR SOBREORUGAS 300-330HP; TRACTOR SOBREORUGAS 170-220HP; RETROEXCAVADORA; MIXER DE CONCRETO; RODILLO BERMERO; RODILLO LISO VIBR. AUTOPROPULSADO 101-135HP 10-12TN; EXCAVACION [1393.96] | EXC |
| A1580 |  | PERFILADO Y COMPACTACION EN ZONA DE CORTE | 2d | 2024-12-30 | 2024-12-31 | A1570, A1640 | 28d | 0d | CAPATAZ [2.36 h]; OPERARIO; OFICIAL [23.58 h]; PEON [23.58 h]; VOLQUETES; CISTERNA [23.58 h]; CAMION GRUA BARANDA 3 TN; CARGADOR FRONTAL; EXCAVADORA SOBRE ORUGAS 180-348 HP [23.58 h]; DUMPER DE DESCARGA FRONTA 2 TN; MOTONIVELADORA 145 -150HP [23.58 h]; TRACTOR SOBREORUGAS 300-330HP; TRACTOR SOBREORUGAS 170-220HP [11.79 h]; RETROEXCAVADORA; MIXER DE CONCRETO; RODILLO BERMERO; RODILLO LISO VIBR. AUTOPROPULSADO 101-135HP 10-12TN [23.58 h]; PERFILADO [7074.04] | EXC |
| A1590 |  | CONFORMACIÓN DE CUERPO DE DIQUE NATURALZADO CON RELLENO COMPACTADO | 4d | 2025-01-16 | 2025-01-19 | A1580, A1650 | 13d | 0d | CAPATAZ [7.5 h]; OPERARIO [75.04 h]; OFICIAL [75.04 h]; PEON [150.08 h]; VOLQUETES; CISTERNA [75.04 h]; CAMION GRUA BARANDA 3 TN; CARGADOR FRONTAL [18.76 h]; EXCAVADORA SOBRE ORUGAS 180-348 HP; DUMPER DE DESCARGA FRONTA 2 TN; MOTONIVELADORA 145 -150HP [75.04 h]; TRACTOR SOBREORUGAS 300-330HP; TRACTOR SOBREORUGAS 170-220HP; RETROEXCAVADORA; MIXER DE CONCRETO; RODILLO BERMERO; RODILLO LISO VIBR. AUTOPROPULSADO 101-135HP 10-12TN [75.04 h]; RELLENOS [3751.91] | RELL |
| A1600 |  | EXCAVACIÓN MANUAL PARA INSTALACIÓN DE BORDILLOS Y CIMENTACIONES | 5d | 2025-02-02 | 2025-02-06 | A1590, A1660 | 0d |  | CAPATAZ; OPERARIO; OFICIAL [87.67 h]; PEON [350.67 h]; VOLQUETES; CISTERNA; CAMION GRUA BARANDA 3 TN; CARGADOR FRONTAL; EXCAVADORA SOBRE ORUGAS 180-348 HP; DUMPER DE DESCARGA FRONTA 2 TN; MOTONIVELADORA 145 -150HP; TRACTOR SOBREORUGAS 300-330HP; TRACTOR SOBREORUGAS 170-220HP; RETROEXCAVADORA; MIXER DE CONCRETO; RODILLO BERMERO; RODILLO LISO VIBR. AUTOPROPULSADO 101-135HP 10-12TN | EXC-MAN |
| A1610 |  | EXCAVACIÓN PARA MEJORAMIENTO DE SUELO CON TIERRA VEGETAL | 1d | 2025-02-22 | 2025-02-22 | A1600, A1670 | 8d | 0d | CAPATAZ [0.03 h]; OPERARIO [0.34 h]; OFICIAL [0.17 h]; PEON [0.34 h]; VOLQUETES; CISTERNA; CAMION GRUA BARANDA 3 TN; CARGADOR FRONTAL; EXCAVADORA SOBRE ORUGAS 180-348 HP [0.34 h]; DUMPER DE DESCARGA FRONTA 2 TN; MOTONIVELADORA 145 -150HP; TRACTOR SOBREORUGAS 300-330HP [0.17 h]; TRACTOR SOBREORUGAS 170-220HP; RETROEXCAVADORA; MIXER DE CONCRETO; RODILLO BERMERO; RODILLO LISO VIBR. AUTOPROPULSADO 101-135HP 10-12TN | EXC |
|  | 7 | **PK 2+922 A PK 3+176** |  | 2024-12-28 | 2025-02-23 |  |  |  |  |  |
| A1070 |  | CORTE PARA CIMENTACIÓN DE DIQUE NATURALIZADO h=30cm | 1d | 2024-12-28 | 2024-12-28 | A1570 | 36d | 3d | CAPATAZ [14.15 h]; OPERARIO [14.15 h]; OFICIAL [14.15 h]; PEON [84.89 h]; VOLQUETES; CISTERNA; CAMION GRUA BARANDA 3 TN; CARGADOR FRONTAL; EXCAVADORA SOBRE ORUGAS 180-348 HP [14.15 h]; DUMPER DE DESCARGA FRONTA 2 TN; MOTONIVELADORA 145 -150HP; TRACTOR SOBREORUGAS 300-330HP; TRACTOR SOBREORUGAS 170-220HP; RETROEXCAVADORA; MIXER DE CONCRETO; RODILLO BERMERO; RODILLO LISO VIBR. AUTOPROPULSADO 101-135HP 10-12TN; EXCAVACION [919.65] | EXC |
| A1080 |  | PERFILADO Y COMPACTACION EN ZONA DE CORTE | 1d | 2025-01-01 | 2025-01-01 | A1070, A1580 | 33d | 18d | CAPATAZ [1.56 h]; OPERARIO; OFICIAL [15.56 h]; PEON [15.56 h]; VOLQUETES; CISTERNA [15.56 h]; CAMION GRUA BARANDA 3 TN; CARGADOR FRONTAL; EXCAVADORA SOBRE ORUGAS 180-348 HP [15.56 h]; DUMPER DE DESCARGA FRONTA 2 TN; MOTONIVELADORA 145 -150HP [15.56 h]; TRACTOR SOBREORUGAS 300-330HP; TRACTOR SOBREORUGAS 170-220HP [7.78 h]; RETROEXCAVADORA; MIXER DE CONCRETO; RODILLO BERMERO; RODILLO LISO VIBR. AUTOPROPULSADO 101-135HP 10-12TN [15.56 h]; PERFILADO [4667.03] | EXC |
| A1090 |  | CONFORMACIÓN DE CUERPO DE DIQUE NATURALZADO CON RELLENO COMPACTADO | 3d | 2025-01-20 | 2025-01-22 | A1080, A1590 | 15d |  | CAPATAZ [4.95 h]; OPERARIO [49.51 h]; OFICIAL [49.51 h]; PEON [99.01 h]; VOLQUETES; CISTERNA [49.51 h]; CAMION GRUA BARANDA 3 TN; CARGADOR FRONTAL [12.38 h]; EXCAVADORA SOBRE ORUGAS 180-348 HP; DUMPER DE DESCARGA FRONTA 2 TN; MOTONIVELADORA 145 -150HP [49.51 h]; TRACTOR SOBREORUGAS 300-330HP; TRACTOR SOBREORUGAS 170-220HP; RETROEXCAVADORA; MIXER DE CONCRETO; RODILLO BERMERO; RODILLO LISO VIBR. AUTOPROPULSADO 101-135HP 10-12TN [49.51 h]; RELLENOS [2475.29] | RELL |
| A1100 |  | EXCAVACIÓN MANUAL PARA INSTALACIÓN DE BORDILLOS Y CIMENTACIONES | 3d | 2025-02-07 | 2025-02-09 | A1090, A1600 | 0d |  | CAPATAZ; OPERARIO; OFICIAL [57.84 h]; PEON [231.35 h]; VOLQUETES; CISTERNA; CAMION GRUA BARANDA 3 TN; CARGADOR FRONTAL; EXCAVADORA SOBRE ORUGAS 180-348 HP; DUMPER DE DESCARGA FRONTA 2 TN; MOTONIVELADORA 145 -150HP; TRACTOR SOBREORUGAS 300-330HP; TRACTOR SOBREORUGAS 170-220HP; RETROEXCAVADORA; MIXER DE CONCRETO; RODILLO BERMERO; RODILLO LISO VIBR. AUTOPROPULSADO 101-135HP 10-12TN | EXC-MAN |
| A1110 |  | EXCAVACIÓN PARA MEJORAMIENTO DE SUELO CON TIERRA VEGETAL | 1d | 2025-02-23 | 2025-02-23 | A1100, A1610 | 8d | 0d | CAPATAZ [0.02 h]; OPERARIO [0.23 h]; OFICIAL [0.11 h]; PEON [0.23 h]; VOLQUETES; CISTERNA; CAMION GRUA BARANDA 3 TN; CARGADOR FRONTAL; EXCAVADORA SOBRE ORUGAS 180-348 HP [0.23 h]; DUMPER DE DESCARGA FRONTA 2 TN; MOTONIVELADORA 145 -150HP; TRACTOR SOBREORUGAS 300-330HP [0.11 h]; TRACTOR SOBREORUGAS 170-220HP; RETROEXCAVADORA; MIXER DE CONCRETO; RODILLO BERMERO; RODILLO LISO VIBR. AUTOPROPULSADO 101-135HP 10-12TN | EXC |
|  | 2 | **FASE 2 - TRAMOS CON RESTRICCION PREDIAL** |  | 2024-12-01 | 2025-04-03 |  |  |  |  |  |
|  | 2 | **MOVIMIENTO DE TIERRAS** |  | 2024-12-01 | 2025-04-03 |  |  |  |  |  |
| A1860 |  | ELIMINACION DE MATERIAL EXCEDENTE (DME´S) | 0d | 2024-12-01 | 2024-12-01 |  | 205d |  | CAPATAZ; OPERARIO; OFICIAL; PEON; VOLQUETES; CISTERNA; CAMION GRUA BARANDA 3 TN; CARGADOR FRONTAL; EXCAVADORA SOBRE ORUGAS 180-348 HP; DUMPER DE DESCARGA FRONTA 2 TN; MOTONIVELADORA 145 -150HP; TRACTOR SOBREORUGAS 300-330HP; TRACTOR SOBREORUGAS 170-220HP; RETROEXCAVADORA; MIXER DE CONCRETO; RODILLO BERMERO; RODILLO LISO VIBR. AUTOPROPULSADO 101-135HP 10-12TN |  |
| A1810 |  | CORTE PARA CIMENTACIÓN DE DIQUE NATURALIZADO h=30cm | 4d | 2025-02-10 | 2025-02-13 | A1100 | 0d |  | EXCAVACION [4732.22]; CAPATAZ [72.8 h]; OPERARIO [72.8 h]; OFICIAL [72.8 h]; PEON [436.82 h]; VOLQUETES; CISTERNA; CAMION GRUA BARANDA 3 TN; CARGADOR FRONTAL; EXCAVADORA SOBRE ORUGAS 180-348 HP [72.8 h]; DUMPER DE DESCARGA FRONTA 2 TN; MOTONIVELADORA 145 -150HP; TRACTOR SOBREORUGAS 300-330HP; TRACTOR SOBREORUGAS 170-220HP; RETROEXCAVADORA; MIXER DE CONCRETO; RODILLO BERMERO; RODILLO LISO VIBR. AUTOPROPULSADO 101-135HP 10-12TN | EXC |
| A1820 |  | PERFILADO Y COMPACTACION EN ZONA DE CORTE | 5d | 2025-02-14 | 2025-02-18 | A1810 | 0d |  | CAPATAZ [8 h]; OPERARIO; OFICIAL [80.05 h]; PEON [80.05 h]; VOLQUETES; CISTERNA [80.05 h]; CAMION GRUA BARANDA 3 TN; CARGADOR FRONTAL; EXCAVADORA SOBRE ORUGAS 180-348 HP [80.05 h]; DUMPER DE DESCARGA FRONTA 2 TN; MOTONIVELADORA 145 -150HP [80.05 h]; TRACTOR SOBREORUGAS 300-330HP; TRACTOR SOBREORUGAS 170-220HP [40.02 h]; RETROEXCAVADORA; MIXER DE CONCRETO; RODILLO BERMERO; RODILLO LISO VIBR. AUTOPROPULSADO 101-135HP 10-12TN [80.05 h]; PERFILADO [24015] | EXC |
| A1830 |  | CONFORMACIÓN DE CUERPO DE DIQUE NATURALZADO CON RELLENO COMPACTADO | 13d | 2025-02-19 | 2025-03-03 | A1820, A1090 | 0d |  | CAPATAZ [25.47 h]; OPERARIO [254.74 h]; OFICIAL [254.74 h]; PEON [509.48 h]; VOLQUETES; CISTERNA [254.74 h]; CAMION GRUA BARANDA 3 TN; CARGADOR FRONTAL [63.69 h]; EXCAVADORA SOBRE ORUGAS 180-348 HP; DUMPER DE DESCARGA FRONTA 2 TN; MOTONIVELADORA 145 -150HP [254.74 h]; TRACTOR SOBREORUGAS 300-330HP; TRACTOR SOBREORUGAS 170-220HP; RETROEXCAVADORA; MIXER DE CONCRETO; RODILLO BERMERO; RODILLO LISO VIBR. AUTOPROPULSADO 101-135HP 10-12TN [254.74 h]; RELLENOS [12737] | RELL |
| A1840 |  | EXCAVACIÓN MANUAL PARA INSTALACIÓN DE BORDILLOS Y CIMENTACIONES | 30d | 2025-03-04 | 2025-04-02 | A1830, A1110 | 0d |  | CAPATAZ; OPERARIO; OFICIAL [297.62 h]; PEON [1190.47 h]; VOLQUETES; CISTERNA; CAMION GRUA BARANDA 3 TN; CARGADOR FRONTAL; EXCAVADORA SOBRE ORUGAS 180-348 HP; DUMPER DE DESCARGA FRONTA 2 TN; MOTONIVELADORA 145 -150HP; TRACTOR SOBREORUGAS 300-330HP; TRACTOR SOBREORUGAS 170-220HP; RETROEXCAVADORA; MIXER DE CONCRETO; RODILLO BERMERO; RODILLO LISO VIBR. AUTOPROPULSADO 101-135HP 10-12TN | EXC-MAN |
| A1850 |  | EXCAVACIÓN PARA MEJORAMIENTO DE SUELO CON TIERRA VEGETAL | 1d | 2025-04-03 | 2025-04-03 | A1840 | 0d |  | CAPATAZ [0.12 h]; OPERARIO [1.16 h]; OFICIAL [0.58 h]; PEON [1.16 h]; VOLQUETES; CISTERNA; CAMION GRUA BARANDA 3 TN; CARGADOR FRONTAL; EXCAVADORA SOBRE ORUGAS 180-348 HP [1.16 h]; DUMPER DE DESCARGA FRONTA 2 TN; MOTONIVELADORA 145 -150HP; TRACTOR SOBREORUGAS 300-330HP [0.58 h]; TRACTOR SOBREORUGAS 170-220HP; RETROEXCAVADORA; MIXER DE CONCRETO; RODILLO BERMERO; RODILLO LISO VIBR. AUTOPROPULSADO 101-135HP 10-12TN | EXC |

| ID | WBS | Activity | Duration | Start | Finish | Predecessors | Total float | Free float | Resources | Licitacion |
| --- | --- | --- | --- | --- | --- | --- | --- | --- | --- | --- |
|  | 3 | **PAVIMENTOS, RECUBRIMIENTOS Y BORDILLOS** |  | 2025-01-20 | 2025-05-04 |  |  |  |  |  |
| A1490 |  | BORDILLOS DE PIEDRA DEL LUGAR | 38d | 2025-01-20 | 2025-02-26 | A1780 | 35d |  | CAPATAZ [747.8 h]; OPERARIO [1495.6 h]; OFICIAL [3739 h]; PEON [7478 h]; VOLQUETES; CISTERNA; CAMION GRUA BARANDA 3 TN; CARGADOR FRONTAL; EXCAVADORA SOBRE ORUGAS 180-348 HP; DUMPER DE DESCARGA FRONTA 2 TN; MOTONIVELADORA 145 -150HP; TRACTOR SOBREORUGAS 300-330HP; TRACTOR SOBREORUGAS 170-220HP; RETROEXCAVADORA; MIXER DE CONCRETO; RODILLO BERMERO; RODILLO LISO VIBR. AUTOPROPULSADO 101-135HP 10-12TN; BORDILLOS [7478] |  |
| A1470 |  | PISO TIERRA APISONADA (h=0.35cm) | 28d | 2025-04-03 | 2025-04-30 | A1490, A1600, A1850 SS | 0d |  | CAPATAZ [107.28 h]; OPERARIO [107.28 h]; OFICIAL [107.28 h]; PEON [2145.55 h]; VOLQUETES; CISTERNA [536.39 h]; CAMION GRUA BARANDA 3 TN; CARGADOR FRONTAL; EXCAVADORA SOBRE ORUGAS 180-348 HP; DUMPER DE DESCARGA FRONTA 2 TN [1072.77 h]; MOTONIVELADORA 145 -150HP; TRACTOR SOBREORUGAS 300-330HP; TRACTOR SOBREORUGAS 170-220HP; RETROEXCAVADORA; MIXER DE CONCRETO [1072.77 h]; RODILLO BERMERO [1072.77 h]; RODILLO LISO VIBR. AUTOPROPULSADO 101-135HP 10-12TN; TIERRA APISONADA [21455.5] |  |
| A1480 |  | RECUBRIMIENTO DE PIEDRA DEL LUGAR e=0.05cm | 4d | 2025-05-01 | 2025-05-04 | A1470 | 0d |  | CAPATAZ [3.13 h]; OPERARIO [31.33 h]; OFICIAL [94 h]; PEON [250.67 h]; VOLQUETES [31.33 h]; CISTERNA [15.67 h]; CAMION GRUA BARANDA 3 TN; CARGADOR FRONTAL; EXCAVADORA SOBRE ORUGAS 180-348 HP; DUMPER DE DESCARGA FRONTA 2 TN; MOTONIVELADORA 145 -150HP; TRACTOR SOBREORUGAS 300-330HP; TRACTOR SOBREORUGAS 170-220HP; RETROEXCAVADORA [31.33 h]; MIXER DE CONCRETO; RODILLO BERMERO; RODILLO LISO VIBR. AUTOPROPULSADO 101-135HP 10-12TN |  |
|  | 4 | **MOBILIARIOS, BARANDAS Y ESCALERAS** |  | 2025-05-05 | 2025-05-20 |  |  |  |  |  |
| A1520 |  | POSTES DE ILUMINACION, INCLUYE LUMINARIA Y CIMENTACION | 3d | 2025-05-05 | 2025-05-07 | A1480 | 0d |  | CAPATAZ [11.88 h]; OPERARIO [2.38 h]; OFICIAL [2.38 h]; PEON [23.75 h]; VOLQUETES; CISTERNA [0.59 h]; CAMION GRUA BARANDA 3 TN; CARGADOR FRONTAL; EXCAVADORA SOBRE ORUGAS 180-348 HP; DUMPER DE DESCARGA FRONTA 2 TN; MOTONIVELADORA 145 -150HP; TRACTOR SOBREORUGAS 300-330HP; TRACTOR SOBREORUGAS 170-220HP; RETROEXCAVADORA; MIXER DE CONCRETO; RODILLO BERMERO; RODILLO LISO VIBR. AUTOPROPULSADO 101-135HP 10-12TN |  |
| A1530 |  | SEÑALETICA INFORMATIVA | 7d | 2025-05-05 | 2025-05-11 | A1520 SS | 0d |  | CAPATAZ; OPERARIO; OFICIAL; PEON; VOLQUETES; CISTERNA; CAMION GRUA BARANDA 3 TN; CARGADOR FRONTAL; EXCAVADORA SOBRE ORUGAS 180-348 HP; DUMPER DE DESCARGA FRONTA 2 TN; MOTONIVELADORA 145 -150HP; TRACTOR SOBREORUGAS 300-330HP; TRACTOR SOBREORUGAS 170-220HP; RETROEXCAVADORA; MIXER DE CONCRETO; RODILLO BERMERO; RODILLO LISO VIBR. AUTOPROPULSADO 101-135HP 10-12TN |  |
| A1500 |  | TACHOS DE BASURA, INCLUYE CIMENTACIÓN | 1.6d | 2025-05-12 | 2025-05-13 | A1530 | 41.4d |  | CAPATAZ [7.92 h]; OPERARIO [15.83 h]; OFICIAL [1.58 h]; PEON [63.33 h]; VOLQUETES; CISTERNA [7.92 h]; CAMION GRUA BARANDA 3 TN; CARGADOR FRONTAL; EXCAVADORA SOBRE ORUGAS 180-348 HP; DUMPER DE DESCARGA FRONTA 2 TN; MOTONIVELADORA 145 -150HP; TRACTOR SOBREORUGAS 300-330HP; TRACTOR SOBREORUGAS 170-220HP; RETROEXCAVADORA; MIXER DE CONCRETO; RODILLO BERMERO; RODILLO LISO VIBR. AUTOPROPULSADO 101-135HP 10-12TN |  |
| A1510 |  | BANCAS DE CONCRETO, INCLUYE CIMENTACIÓN | 5d | 2025-05-12 | 2025-05-16 | A1520, A1530 | 34d | 0d | CAPATAZ [23.75 h]; OPERARIO [47.5 h]; OFICIAL [4.75 h]; PEON [190 h]; VOLQUETES; CISTERNA [1.19 h]; CAMION GRUA BARANDA 3 TN; CARGADOR FRONTAL; EXCAVADORA SOBRE ORUGAS 180-348 HP; DUMPER DE DESCARGA FRONTA 2 TN; MOTONIVELADORA 145 -150HP; TRACTOR SOBREORUGAS 300-330HP; TRACTOR SOBREORUGAS 170-220HP; RETROEXCAVADORA; MIXER DE CONCRETO; RODILLO BERMERO; RODILLO LISO VIBR. AUTOPROPULSADO 101-135HP 10-12TN |  |
| A1550 |  | TRANQUERA | 2d | 2025-05-12 | 2025-05-13 | A1530 | 41d |  | CAPATAZ [1.5 h]; OPERARIO [7.5 h]; OFICIAL [15 h]; PEON [60 h]; VOLQUETES; CISTERNA [0.38 h]; CAMION GRUA BARANDA 3 TN; CARGADOR FRONTAL; EXCAVADORA SOBRE ORUGAS 180-348 HP; DUMPER DE DESCARGA FRONTA 2 TN; MOTONIVELADORA 145 -150HP; TRACTOR SOBREORUGAS 300-330HP; TRACTOR SOBREORUGAS 170-220HP; RETROEXCAVADORA; MIXER DE CONCRETO; RODILLO BERMERO; RODILLO LISO VIBR. AUTOPROPULSADO 101-135HP 10-12TN |  |
| A1540 |  | BOLARDOS DE PIEDRA | 4d | 2025-05-17 | 2025-05-20 | A1520, A1510 | 34d |  | CAPATAZ [3.83 h]; OPERARIO [3.83 h]; OFICIAL [38.25 h]; PEON [382.5 h]; VOLQUETES [19.12 h]; CISTERNA; CAMION GRUA BARANDA 3 TN; CARGADOR FRONTAL; EXCAVADORA SOBRE ORUGAS 180-348 HP; DUMPER DE DESCARGA FRONTA 2 TN; MOTONIVELADORA 145 -150HP; TRACTOR SOBREORUGAS 300-330HP; TRACTOR SOBREORUGAS 170-220HP; RETROEXCAVADORA [19.12 h]; MIXER DE CONCRETO; RODILLO BERMERO; RODILLO LISO VIBR. AUTOPROPULSADO 101-135HP 10-12TN |  |
|  | 8 | **OBRAS PRELIMINARES PAISAJISMO** |  | 2025-05-05 | 2025-06-12 |  |  |  |  |  |
| A1560 |  | MEJORAMIENTO DE SUELO CON TIERRA DE CHACRA (incluye despedregado y rastrillado) | 39d | 2025-05-05 | 2025-06-12 | A1480 | 11d |  | CAPATAZ [38.54 h]; OPERARIO [770.87 h]; OFICIAL [1541.74 h]; PEON [3854.36 h]; VOLQUETES; CISTERNA [192.72 h]; CAMION GRUA BARANDA 3 TN [192.72 h]; CARGADOR FRONTAL; EXCAVADORA SOBRE ORUGAS 180-348 HP; DUMPER DE DESCARGA FRONTA 2 TN; MOTONIVELADORA 145 -150HP [192.72 h]; TRACTOR SOBREORUGAS 300-330HP; TRACTOR SOBREORUGAS 170-220HP; RETROEXCAVADORA; MIXER DE CONCRETO; RODILLO BERMERO; RODILLO LISO VIBR. AUTOPROPULSADO 101-135HP 10-12TN |  |
|  | 5 | **INTERVENCIÓN PAISAJISMO - HUMEDAL VILLA MARIA MARGEN IZQUIERDO** |  | 2024-12-01 | 2025-06-23 |  |  |  |  |  |
|  | 1 | **OBRAS PRELIMINARES** |  | 2024-12-01 | 2025-05-07 |  |  |  |  |  |
| A1230 |  | MOVILIZACIÓN Y DEMOVILIZACIÓN DE EQUIPOS Y HERRAMIENTAS (ARQUITECTURA Y PAISAJISMO) | 16d | 2024-12-01 | 2024-12-16 | H1000 SS | 53d | 22d | CAPATAZ; OPERARIO; OFICIAL; PEON; VOLQUETES; CISTERNA; CAMION GRUA BARANDA 3 TN; CARGADOR FRONTAL; EXCAVADORA SOBRE ORUGAS 180-348 HP; DUMPER DE DESCARGA FRONTA 2 TN; MOTONIVELADORA 145 -150HP; TRACTOR SOBREORUGAS 300-330HP; TRACTOR SOBREORUGAS 170-220HP; RETROEXCAVADORA; MIXER DE CONCRETO; RODILLO BERMERO; RODILLO LISO VIBR. AUTOPROPULSADO 101-135HP 10-12TN |  |
| A1240 |  | TRAZO Y REPLANTEO PRELIMINAR | 25d | 2025-01-08 | 2025-02-01 | A1050, A1230 | 31d | 22d | CAPATAZ; OPERARIO [484.28 h]; OFICIAL [484.28 h]; PEON [968.55 h]; VOLQUETES; CISTERNA; CAMION GRUA BARANDA 3 TN; CARGADOR FRONTAL; EXCAVADORA SOBRE ORUGAS 180-348 HP; DUMPER DE DESCARGA FRONTA 2 TN; MOTONIVELADORA 145 -150HP; TRACTOR SOBREORUGAS 300-330HP; TRACTOR SOBREORUGAS 170-220HP; RETROEXCAVADORA; MIXER DE CONCRETO; RODILLO BERMERO; RODILLO LISO VIBR. AUTOPROPULSADO 101-135HP 10-12TN |  |
| A1250 |  | ELIMINACION DE RESIDUOS SOLIDOS GENERALES MUNICIPALES | 70d | 2025-02-27 | 2025-05-07 | A1060 SS, A1260 | 11d |  | CAPATAZ [278.32 h]; OPERARIO [278.32 h]; OFICIAL [1391.6 h]; PEON [2783.19 h]; VOLQUETES [2783.19 h]; CISTERNA; CAMION GRUA BARANDA 3 TN; CARGADOR FRONTAL; EXCAVADORA SOBRE ORUGAS 180-348 HP [2783.19 h]; DUMPER DE DESCARGA FRONTA 2 TN; MOTONIVELADORA 145 -150HP; TRACTOR SOBREORUGAS 300-330HP [1391.6 h]; TRACTOR SOBREORUGAS 170-220HP; RETROEXCAVADORA; MIXER DE CONCRETO; RODILLO BERMERO; RODILLO LISO VIBR. AUTOPROPULSADO 101-135HP 10-12TN; EXCAVACION [48705.9] |  |
|  | 6 | **FASE 1 - TRAMOS SIN RESTRICCION PREDIAL** |  | 2024-12-01 | 2025-04-01 |  |  |  |  |  |
|  | 2 | **MOVIMIENTO DE TIERRAS** |  | 2024-12-01 | 2025-04-01 |  |  |  |  |  |
|  | 1 | **PK 0+000 - PK 0+100** |  | 2024-12-01 | 2025-03-03 |  |  |  |  |  |
| A1300 |  | ELIMINACION DE MATERIAL EXCEDENTE (DME´S) | 0d | 2024-12-01 | 2024-12-01 |  | 205d |  | CAPATAZ; OPERARIO; OFICIAL; PEON; VOLQUETES; CISTERNA; CAMION GRUA BARANDA 3 TN; CARGADOR FRONTAL; EXCAVADORA SOBRE ORUGAS 180-348 HP; DUMPER DE DESCARGA FRONTA 2 TN; MOTONIVELADORA 145 -150HP; TRACTOR SOBREORUGAS 300-330HP; TRACTOR SOBREORUGAS 170-220HP; RETROEXCAVADORA; MIXER DE CONCRETO; RODILLO BERMERO; RODILLO LISO VIBR. AUTOPROPULSADO 101-135HP 10-12TN |  |
| A1260 |  | CORTE PARA CIMENTACIÓN DE DIQUE NATURALIZADO h=30cm | 3d | 2025-02-24 | 2025-02-26 | A1240, A1110 | 9d | 0d | CAPATAZ [47.57 h]; OPERARIO [47.57 h]; OFICIAL [47.57 h]; PEON [285.41 h]; VOLQUETES; CISTERNA; CAMION GRUA BARANDA 3 TN; CARGADOR FRONTAL; EXCAVADORA SOBRE ORUGAS 180-348 HP [47.57 h]; DUMPER DE DESCARGA FRONTA 2 TN; MOTONIVELADORA 145 -150HP; TRACTOR SOBREORUGAS 300-330HP; TRACTOR SOBREORUGAS 170-220HP; RETROEXCAVADORA; MIXER DE CONCRETO; RODILLO BERMERO; RODILLO LISO VIBR. AUTOPROPULSADO 101-135HP 10-12TN; EXCAVACION [3091.93] | EXC |
| A1270 |  | PERFILADO Y COMPACTACION EN ZONA DE CORTE | 1d | 2025-02-27 | 2025-02-27 | A1260 | 9d | 0d | CAPATAZ [1.97 h]; OPERARIO; OFICIAL [19.66 h]; PEON [19.66 h]; VOLQUETES; CISTERNA [19.66 h]; CAMION GRUA BARANDA 3 TN; CARGADOR FRONTAL; EXCAVADORA SOBRE ORUGAS 180-348 HP [19.66 h]; DUMPER DE DESCARGA FRONTA 2 TN; MOTONIVELADORA 145 -150HP [19.66 h]; TRACTOR SOBREORUGAS 300-330HP; TRACTOR SOBREORUGAS 170-220HP [9.83 h]; RETROEXCAVADORA; MIXER DE CONCRETO; RODILLO BERMERO; RODILLO LISO VIBR. AUTOPROPULSADO 101-135HP 10-12TN [19.66 h]; PERFILADO [5898.62] | EXC |
| A1280 |  | CONFORMACIÓN DE DIQUE NATURALIZADO O TERRAZA CON RELLENO COMPACTADO | 1d | 2025-02-28 | 2025-02-28 | A1270 | 112d | 0d | CAPATAZ [1.07 h]; OPERARIO [10.7 h]; OFICIAL [10.7 h]; PEON [21.4 h]; VOLQUETES; CISTERNA [10.7 h]; CAMION GRUA BARANDA 3 TN; CARGADOR FRONTAL [2.67 h]; EXCAVADORA SOBRE ORUGAS 180-348 HP; DUMPER DE DESCARGA FRONTA 2 TN; MOTONIVELADORA 145 -150HP [10.7 h]; TRACTOR SOBREORUGAS 300-330HP; TRACTOR SOBREORUGAS 170-220HP; RETROEXCAVADORA; MIXER DE CONCRETO; RODILLO BERMERO; RODILLO LISO VIBR. AUTOPROPULSADO 101-135HP 10-12TN [10.7 h]; RELLENOS [534.98] | RELL |
| A1290 |  | EXCAVACIÓN MANUAL PARA INSTALACIÓN DE BORDILLOS Y CIMENTACIONES | 3d | 2025-03-01 | 2025-03-03 | A1280 | 112d |  | CAPATAZ; OPERARIO; OFICIAL [20.41 h]; PEON [81.66 h]; VOLQUETES; CISTERNA; CAMION GRUA BARANDA 3 TN; CARGADOR FRONTAL; EXCAVADORA SOBRE ORUGAS 180-348 HP; DUMPER DE DESCARGA FRONTA 2 TN; MOTONIVELADORA 145 -150HP; TRACTOR SOBREORUGAS 300-330HP; TRACTOR SOBREORUGAS 170-220HP; RETROEXCAVADORA; MIXER DE CONCRETO; RODILLO BERMERO; RODILLO LISO VIBR. AUTOPROPULSADO 101-135HP 10-12TN | EXC-MAN |

| ID | WBS | Activity | Duration | Start | Finish | Predecessors | Total float | Free float | Resources | Licitacion |
| --- | --- | --- | --- | --- | --- | --- | --- | --- | --- | --- |
|  | 2 | **PK 0+300 - PK 0+821** |  | 2024-12-01 | 2025-04-01 |  |  |  |  |  |
| A1960 |  | ELIMINACION DE MATERIAL EXCEDENTE (DME´S) | 0d | 2024-12-01 | 2024-12-01 |  | 205d |  | CAPATAZ; OPERARIO; OFICIAL; PEON; VOLQUETES; CISTERNA; CAMION GRUA BARANDA 3 TN; CARGADOR FRONTAL; EXCAVADORA SOBRE ORUGAS 180-348 HP; DUMPER DE DESCARGA FRONTA 2 TN; MOTONIVELADORA 145 -150HP; TRACTOR SOBREORUGAS 300-330HP; TRACTOR SOBREORUGAS 170-220HP; RETROEXCAVADORA; MIXER DE CONCRETO; RODILLO BERMERO; RODILLO LISO VIBR. AUTOPROPULSADO 101-135HP 10-12TN |  |
| A1920 |  | CORTE PARA CIMENTACIÓN DE DIQUE NATURALIZADO h=30cm | 13d | 2025-02-28 | 2025-03-12 | A1270 | 9d | 0d | CAPATAZ [247.83 h]; OPERARIO [247.83 h]; OFICIAL [247.83 h]; PEON [1486.98 h]; VOLQUETES; CISTERNA; CAMION GRUA BARANDA 3 TN; CARGADOR FRONTAL; EXCAVADORA SOBRE ORUGAS 180-348 HP [247.83 h]; DUMPER DE DESCARGA FRONTA 2 TN; MOTONIVELADORA 145 -150HP; TRACTOR SOBREORUGAS 300-330HP; TRACTOR SOBREORUGAS 170-220HP; RETROEXCAVADORA; MIXER DE CONCRETO; RODILLO BERMERO; RODILLO LISO VIBR. AUTOPROPULSADO 101-135HP 10-12TN; EXCAVACION [16108.9] | EXC |
| A1930 |  | PERFILADO Y COMPACTACION EN ZONA DE CORTE | 6d | 2025-03-13 | 2025-03-18 | A1920 | 9d | 0d | CAPATAZ [10.24 h]; OPERARIO; OFICIAL [102.44 h]; PEON [102.44 h]; VOLQUETES; CISTERNA [102.44 h]; CAMION GRUA BARANDA 3 TN; CARGADOR FRONTAL; EXCAVADORA SOBRE ORUGAS 180-348 HP [102.44 h]; DUMPER DE DESCARGA FRONTA 2 TN; MOTONIVELADORA 145 -150HP [102.44 h]; TRACTOR SOBREORUGAS 300-330HP; TRACTOR SOBREORUGAS 170-220HP [51.22 h]; RETROEXCAVADORA; MIXER DE CONCRETO; RODILLO BERMERO; RODILLO LISO VIBR. AUTOPROPULSADO 101-135HP 10-12TN [102.44 h]; PERFILADO [30731.8] | EXC |
| A1940 |  | CONFORMACIÓN DE DIQUE NATURALIZADO O TERRAZA CON RELLENO COMPACTADO | 3d | 2025-03-19 | 2025-03-21 | A1930 | 9d | 0d | CAPATAZ [5.57 h]; OPERARIO [55.75 h]; OFICIAL [55.75 h]; PEON [111.49 h]; VOLQUETES; CISTERNA [55.75 h]; CAMION GRUA BARANDA 3 TN; CARGADOR FRONTAL [13.94 h]; EXCAVADORA SOBRE ORUGAS 180-348 HP; DUMPER DE DESCARGA FRONTA 2 TN; MOTONIVELADORA 145 -150HP [55.75 h]; TRACTOR SOBREORUGAS 300-330HP; TRACTOR SOBREORUGAS 170-220HP; RETROEXCAVADORA; MIXER DE CONCRETO; RODILLO BERMERO; RODILLO LISO VIBR. AUTOPROPULSADO 101-135HP 10-12TN [55.75 h]; RELLENOS [2787.27] | RELL |
| A1950 |  | EXCAVACIÓN MANUAL PARA INSTALACIÓN DE BORDILLOS Y CIMENTACIONES | 11d | 2025-03-22 | 2025-04-01 | A1940 | 9d | 0d | CAPATAZ; OPERARIO; OFICIAL [106.36 h]; PEON [425.43 h]; VOLQUETES; CISTERNA; CAMION GRUA BARANDA 3 TN; CARGADOR FRONTAL; EXCAVADORA SOBRE ORUGAS 180-348 HP; DUMPER DE DESCARGA FRONTA 2 TN; MOTONIVELADORA 145 -150HP; TRACTOR SOBREORUGAS 300-330HP; TRACTOR SOBREORUGAS 170-220HP; RETROEXCAVADORA; MIXER DE CONCRETO; RODILLO BERMERO; RODILLO LISO VIBR. AUTOPROPULSADO 101-135HP 10-12TN | EXC-MAN |
|  | 2 | **FASE 2 - TRAMOS CON RESTRICCION PREDIAL-1** |  | 2024-12-01 | 2025-04-13 |  |  |  |  |  |
|  | 2 | **MOVIMIENTO DE TIERRAS** |  | 2024-12-01 | 2025-04-13 |  |  |  |  |  |
|  | 1 | **PK 0+100 - PK 0+300** |  | 2024-12-01 | 2025-04-13 |  |  |  |  |  |
| A1910 |  | ELIMINACION DE MATERIAL EXCEDENTE (DME´S) | 0d | 2024-12-01 | 2024-12-01 |  | 205d |  | CAPATAZ; OPERARIO; OFICIAL; PEON; VOLQUETES; CISTERNA; CAMION GRUA BARANDA 3 TN; CARGADOR FRONTAL; EXCAVADORA SOBRE ORUGAS 180-348 HP; DUMPER DE DESCARGA FRONTA 2 TN; MOTONIVELADORA 145 -150HP; TRACTOR SOBREORUGAS 300-330HP; TRACTOR SOBREORUGAS 170-220HP; RETROEXCAVADORA; MIXER DE CONCRETO; RODILLO BERMERO; RODILLO LISO VIBR. AUTOPROPULSADO 101-135HP 10-12TN |  |
| A1870 |  | CORTE PARA CIMENTACIÓN DE DIQUE NATURALIZADO h=30cm | 10d | 2025-03-19 | 2025-03-28 | A1930, A1820 | 71d | 0d | CAPATAZ [95.14 h]; OPERARIO [95.14 h]; OFICIAL [95.14 h]; PEON [570.82 h]; VOLQUETES; CISTERNA; CAMION GRUA BARANDA 3 TN; CARGADOR FRONTAL; EXCAVADORA SOBRE ORUGAS 180-348 HP [95.14 h]; DUMPER DE DESCARGA FRONTA 2 TN; MOTONIVELADORA 145 -150HP; TRACTOR SOBREORUGAS 300-330HP; TRACTOR SOBREORUGAS 170-220HP; RETROEXCAVADORA; MIXER DE CONCRETO; RODILLO BERMERO; RODILLO LISO VIBR. AUTOPROPULSADO 101-135HP 10-12TN; EXCAVACION [6183.85] | EXC |
| A1880 |  | PERFILADO Y COMPACTACION EN ZONA DE CORTE | 4d | 2025-03-29 | 2025-04-01 | A1870 | 71d | 0d | CAPATAZ [3.93 h]; OPERARIO; OFICIAL [39.32 h]; PEON [39.32 h]; VOLQUETES; CISTERNA [39.32 h]; CAMION GRUA BARANDA 3 TN; CARGADOR FRONTAL; EXCAVADORA SOBRE ORUGAS 180-348 HP [39.32 h]; DUMPER DE DESCARGA FRONTA 2 TN; MOTONIVELADORA 145 -150HP [39.32 h]; TRACTOR SOBREORUGAS 300-330HP; TRACTOR SOBREORUGAS 170-220HP [19.66 h]; RETROEXCAVADORA; MIXER DE CONCRETO; RODILLO BERMERO; RODILLO LISO VIBR. AUTOPROPULSADO 101-135HP 10-12TN [39.32 h]; PERFILADO [11797.2] | EXC |
| A1890 |  | CONFORMACIÓN DE DIQUE NATURALIZADO O TERRAZA CON RELLENO COMPACTADO | 3d | 2025-04-02 | 2025-04-04 | A1880, A1000 FF, A1010 FF | 71d | 0d | CAPATAZ [2.14 h]; OPERARIO [21.4 h]; OFICIAL [21.4 h]; PEON [42.8 h]; VOLQUETES; CISTERNA [21.4 h]; CAMION GRUA BARANDA 3 TN; CARGADOR FRONTAL [5.35 h]; EXCAVADORA SOBRE ORUGAS 180-348 HP; DUMPER DE DESCARGA FRONTA 2 TN; MOTONIVELADORA 145 -150HP [21.4 h]; TRACTOR SOBREORUGAS 300-330HP; TRACTOR SOBREORUGAS 170-220HP; RETROEXCAVADORA; MIXER DE CONCRETO; RODILLO BERMERO; RODILLO LISO VIBR. AUTOPROPULSADO 101-135HP 10-12TN [21.4 h]; RELLENOS [1069.97] | RELL |
| A1900 |  | EXCAVACIÓN MANUAL PARA INSTALACIÓN DE BORDILLOS Y CIMENTACIONES | 9d | 2025-04-05 | 2025-04-13 | A1890, A1020 FF, A1030 FF | 71d |  | CAPATAZ; OPERARIO; OFICIAL [40.83 h]; PEON [163.31 h]; VOLQUETES; CISTERNA; CAMION GRUA BARANDA 3 TN; CARGADOR FRONTAL; EXCAVADORA SOBRE ORUGAS 180-348 HP; DUMPER DE DESCARGA FRONTA 2 TN; MOTONIVELADORA 145 -150HP; TRACTOR SOBREORUGAS 300-330HP; TRACTOR SOBREORUGAS 170-220HP; RETROEXCAVADORA; MIXER DE CONCRETO; RODILLO BERMERO; RODILLO LISO VIBR. AUTOPROPULSADO 101-135HP 10-12TN | EXC-MAN |
|  | 3 | **PAVIMENTOS, RECUBRIMIENTOS Y BORDILLOS** |  | 2025-04-02 | 2025-05-02 |  |  |  |  |  |
| A1330 |  | BORDILLOS DE PIEDRA DEL LUGAR | 9d | 2025-04-02 | 2025-04-10 | A1950 | 9d | 0d | CAPATAZ [167.6 h]; OPERARIO [335.2 h]; OFICIAL [838 h]; PEON [1676 h]; VOLQUETES; CISTERNA; CAMION GRUA BARANDA 3 TN; CARGADOR FRONTAL; EXCAVADORA SOBRE ORUGAS 180-348 HP; DUMPER DE DESCARGA FRONTA 2 TN; MOTONIVELADORA 145 -150HP; TRACTOR SOBREORUGAS 300-330HP; TRACTOR SOBREORUGAS 170-220HP; RETROEXCAVADORA; MIXER DE CONCRETO; RODILLO BERMERO; RODILLO LISO VIBR. AUTOPROPULSADO 101-135HP 10-12TN; BORDILLOS [1676] |  |
| A1310 |  | PISO TIERRA APISONADA (h=0.35cm) | 20d | 2025-04-11 | 2025-04-30 | A1330 | 9d | 0d | CAPATAZ [39.72 h]; OPERARIO [39.72 h]; OFICIAL [39.72 h]; PEON [794.35 h]; VOLQUETES; CISTERNA [198.59 h]; CAMION GRUA BARANDA 3 TN; CARGADOR FRONTAL; EXCAVADORA SOBRE ORUGAS 180-348 HP; DUMPER DE DESCARGA FRONTA 2 TN [397.18 h]; MOTONIVELADORA 145 -150HP; TRACTOR SOBREORUGAS 300-330HP; TRACTOR SOBREORUGAS 170-220HP; RETROEXCAVADORA; MIXER DE CONCRETO [397.18 h]; RODILLO BERMERO [397.18 h]; RODILLO LISO VIBR. AUTOPROPULSADO 101-135HP 10-12TN; TIERRA APISONADA [7943.53] |  |
| A1320 |  | RECUBRIMIENTO DE PIEDRA DEL LUGAR e=0.05cm | 2d | 2025-05-01 | 2025-05-02 | A1310 | 9d |  | CAPATAZ [1.61 h]; OPERARIO [16.05 h]; OFICIAL [48.16 h]; PEON [128.43 h]; VOLQUETES [16.05 h]; CISTERNA [8.03 h]; CAMION GRUA BARANDA 3 TN; CARGADOR FRONTAL; EXCAVADORA SOBRE ORUGAS 180-348 HP; DUMPER DE DESCARGA FRONTA 2 TN; MOTONIVELADORA 145 -150HP; TRACTOR SOBREORUGAS 300-330HP; TRACTOR SOBREORUGAS 170-220HP; RETROEXCAVADORA [16.05 h]; MIXER DE CONCRETO; RODILLO BERMERO; RODILLO LISO VIBR. AUTOPROPULSADO 101-135HP 10-12TN |  |
|  | 4 | **MOBILIARIOS, BARANDAS Y ESCALERAS** |  | 2025-05-12 | 2025-05-29 |  |  |  |  |  |
| A1360 |  | POSTES DE ILUMINACION, INCLUYE LUMINARIA Y CIMENTACION | 1d | 2025-05-12 | 2025-05-12 | A1320, A1530 | 0d |  | CAPATAZ [3.12 h]; OPERARIO [0.62 h]; OFICIAL [0.62 h]; PEON [6.25 h]; VOLQUETES; CISTERNA [0.16 h]; CAMION GRUA BARANDA 3 TN; CARGADOR FRONTAL; EXCAVADORA SOBRE ORUGAS 180-348 HP; DUMPER DE DESCARGA FRONTA 2 TN; MOTONIVELADORA 145 -150HP; TRACTOR SOBREORUGAS 300-330HP; TRACTOR SOBREORUGAS 170-220HP; RETROEXCAVADORA; MIXER DE CONCRETO; RODILLO BERMERO; RODILLO LISO VIBR. AUTOPROPULSADO 101-135HP 10-12TN |  |
| A1370 |  | SEÑALETICA INFORMATIVA | 2d | 2025-05-13 | 2025-05-14 | A1360 | 0d |  | CAPATAZ; OPERARIO; OFICIAL; PEON; VOLQUETES; CISTERNA; CAMION GRUA BARANDA 3 TN; CARGADOR FRONTAL; EXCAVADORA SOBRE ORUGAS 180-348 HP; DUMPER DE DESCARGA FRONTA 2 TN; MOTONIVELADORA 145 -150HP; TRACTOR SOBREORUGAS 300-330HP; TRACTOR SOBREORUGAS 170-220HP; RETROEXCAVADORA; MIXER DE CONCRETO; RODILLO BERMERO; RODILLO LISO VIBR. AUTOPROPULSADO 101-135HP 10-12TN |  |
| A1350 |  | BANCAS DE CONCRETO, INCLUYE CIMENTACIÓN | 4d | 2025-05-15 | 2025-05-18 | A1370 | 0d |  | CAPATAZ [17.5 h]; OPERARIO [35 h]; OFICIAL [3.5 h]; PEON [140 h]; VOLQUETES; CISTERNA [0.88 h]; CAMION GRUA BARANDA 3 TN; CARGADOR FRONTAL; EXCAVADORA SOBRE ORUGAS 180-348 HP; DUMPER DE DESCARGA FRONTA 2 TN; MOTONIVELADORA 145 -150HP; TRACTOR SOBREORUGAS 300-330HP; TRACTOR SOBREORUGAS 170-220HP; RETROEXCAVADORA; MIXER DE CONCRETO; RODILLO BERMERO; RODILLO LISO VIBR. AUTOPROPULSADO 101-135HP 10-12TN |  |
| A1380 |  | BOLARDOS DE PIEDRA | 10d | 2025-05-19 | 2025-05-28 | A1350 | 25d | 0d | CAPATAZ [19.3 h]; OPERARIO [19.3 h]; OFICIAL [193 h]; PEON [1930 h]; VOLQUETES [96.5 h]; CISTERNA; CAMION GRUA BARANDA 3 TN; CARGADOR FRONTAL; EXCAVADORA SOBRE ORUGAS 180-348 HP; DUMPER DE DESCARGA FRONTA 2 TN; MOTONIVELADORA 145 -150HP; TRACTOR SOBREORUGAS 300-330HP; TRACTOR SOBREORUGAS 170-220HP; RETROEXCAVADORA [96.5 h]; MIXER DE CONCRETO; RODILLO BERMERO; RODILLO LISO VIBR. AUTOPROPULSADO 101-135HP 10-12TN |  |
| A1340 |  | TACHOS DE BASURA, INCLUYE CIMENTACIÓN | 1d | 2025-05-29 | 2025-05-29 | A1390 SS | 25d |  | CAPATAZ [1.67 h]; OPERARIO [3.33 h]; OFICIAL [0.33 h]; PEON [13.33 h]; VOLQUETES; CISTERNA [1.67 h]; CAMION GRUA BARANDA 3 TN; CARGADOR FRONTAL; EXCAVADORA SOBRE ORUGAS 180-348 HP; DUMPER DE DESCARGA FRONTA 2 TN; MOTONIVELADORA 145 -150HP; TRACTOR SOBREORUGAS 300-330HP; TRACTOR SOBREORUGAS 170-220HP; RETROEXCAVADORA; MIXER DE CONCRETO; RODILLO BERMERO; RODILLO LISO VIBR. AUTOPROPULSADO 101-135HP 10-12TN |  |
| A1390 |  | TRANQUERA | 1d | 2025-05-29 | 2025-05-29 | A1380 | 25d | 0d | CAPATAZ [0.25 h]; OPERARIO [1.25 h]; OFICIAL [2.5 h]; PEON [10 h]; VOLQUETES; CISTERNA [0.06 h]; CAMION GRUA BARANDA 3 TN; CARGADOR FRONTAL; EXCAVADORA SOBRE ORUGAS 180-348 HP; DUMPER DE DESCARGA FRONTA 2 TN; MOTONIVELADORA 145 -150HP; TRACTOR SOBREORUGAS 300-330HP; TRACTOR SOBREORUGAS 170-220HP; RETROEXCAVADORA; MIXER DE CONCRETO; RODILLO BERMERO; RODILLO LISO VIBR. AUTOPROPULSADO 101-135HP 10-12TN |  |

| ID | WBS | Activity | Duration | Start | Finish | Predecessors | Total float | Resources |
| --- | --- | --- | --- | --- | --- | --- | --- | --- |
|  | 5 | **OBRAS PRELIMINARES PAISAJISMO** |  | 2025-05-19 | 2025-06-23 |  |  |  |
| A1400 |  | MEJORAMIENTO DE SUELO CON TIERRA DE CHACRA (incluye despedregado y rastrillado) | 36d | 2025-05-19 | 2025-06-23 | A1350, A1250 | 0d | CAPATAZ [35.02 h]; OPERARIO [700.33 h]; OFICIAL [1400.66 h]; PEON [3501.64 h]; VOLQUETES; CISTERNA [175.08 h]; CAMION GRUA BARANDA 3 TN [175.08 h]; CARGADOR FRONTAL; EXCAVADORA SOBRE ORUGAS 180-348 HP; DUMPER DE DESCARGA FRONTA 2 TN; MOTONIVELADORA 145 -150HP [175.08 h]; TRACTOR SOBREORUGAS 300-330HP; TRACTOR SOBREORUGAS 170-220HP; RETROEXCAVADORA; MIXER DE CONCRETO; RODILLO BERMERO; RODILLO LISO VIBR. AUTOPROPULSADO 101-135HP 10-12TN |

## Activity codes

| Code | Value | Meaning |
| --- | --- | --- |
| Licitacion | EXC | EXCAVADORA |
| Licitacion | EXC-MAN | EXCAVACION MANUAL |
| Licitacion | RELL | RELLENO |
